# Hall D Offline Computing

Schedule from Planner, 2009-10-01 to 2012-11-06.

## Calendars

- Default: Mon-Fri 08:00-12:00, 13:00-17:00; Sat-Sun off.

## Resources

| Resource | Rate |
| --- | --- |
| Contributed |  |
| Scientist | 64.26 |

## Schedule

| ID | WBS | Task | Start | Finish | Predecessors | Resources | Work |
| --- | --- | --- | --- | --- | --- | --- | --- |
| 1 | 1 | MC Studies for Detector Optimization [5533010] | 2009-10-01 | 2011-01-05 |  | Contributed; Scientist | 5280h |
| 2 | 2 | Reconstruction Framework [5533015] | 2010-03-12 | 2011-01-13 | 1FS-7200h | Scientist | 1760h |
| 3 | 3 | Integration of Slow Controls [5533020] | 2011-01-14 | 2011-09-01 | 2 | Scientist | 1320h |
| 4 | 4 | DAQ to Detector Translation Table [5533025] | 2011-01-06 | 2011-11-08 | 1 | Contributed; Scientist [10%] | 1920h |
| 5 | 5 | Micro DST Writer [5533030] | 2011-01-14 | 2011-06-16 | 2 | Contributed; Scientist [10%] | 960h |
| 6 | 6 | **Reconstruction** | 2010-06-28 | 2011-09-30 |  |  | 12480h |
| 7 | 6.1 | Track Finding [5533045] | 2010-06-28 | 2011-09-30 | 2FS-4800h | Scientist | 2640h |
| 8 | 6.2 | Track Fitting [5533050] | 2010-06-28 | 2011-09-30 | 2FS-4800h | Scientist | 2640h |
| 9 | 6.3 | BCal Reconstruction [5533055] | 2010-06-28 | 2011-04-28 | 2FS-4800h | Contributed; Scientist [10%] | 1920h |
| 10 | 6.4 | FCal Reconstruction [5533060] | 2010-06-28 | 2011-02-10 | 2FS-4800h | Contributed; Scientist [10%] | 1440h |
| 11 | 6.5 | TOF Reconstruction [5533070] | 2010-06-28 | 2011-02-10 | 2FS-4800h | Contributed; Scientist [10%] | 1440h |
| 12 | 6.6 | Tagger Reconstruction [5533080] | 2010-06-28 | 2011-02-10 | 2FS-4800h | Contributed; Scientist [10%] | 1440h |
| 13 | 6.7 | Start Counter Reconstruction [5533085] | 2010-06-28 | 2010-11-26 | 2FS-4800h | Contributed; Scientist [10%] | 960h |
| 14 | 7 | Particle ID [5533090] | 2011-10-03 | 2012-08-02 | 6 | Contributed; Scientist [10%] | 1920h |
| 15 | 8 | Kinematic Fitter [5533095] | 2011-10-03 | 2012-08-02 | 6 | Contributed; Scientist [10%] | 1920h |
| 16 | 9 | Integration/QC [5533100] | 2010-06-28 | 2011-04-29 | 2FS-4800h | Scientist | 1760h |
| 17 | 10 | Calibration Database [5533105] | 2010-06-28 | 2010-12-10 | 2FS-4800h | Contributed [50%]; Scientist | 1440h |
| 18 | 11 | CDC Calibration [5533110] | 2011-10-03 | 2012-05-17 | 8, 7 | Contributed; Scientist [10%] | 1440h |
| 19 | 12 | FDC Calibration [5533115] | 2011-10-03 | 2012-05-17 | 8, 7 | Contributed; Scientist [10%] | 1440h |
| 20 | 13 | BCal Calibration [5533120] | 2011-04-28 | 2011-12-13 | 9 | Contributed; Scientist [10%] | 1440h |
| 21 | 14 | FCal Calibration [5533125] | 2011-02-10 | 2011-09-28 | 10 | Contributed; Scientist [10%] | 1440h |
| 22 | 15 | Tagger Calibration [5533140] | 2011-02-10 | 2011-09-28 | 12 | Contributed; Scientist [10%] | 1440h |
| 23 | 16 | Starter Counter Calibration [5533145] | 2010-11-26 | 2011-04-28 | 13 | Contributed; Scientist [10%] | 960h |
| 24 | 17 | **Job Control** | 2011-10-03 | 2012-05-18 |  |  | 2760h |
| 25 | 17.1 | Job Control Reconstruction [5533150] | 2011-10-03 | 2012-05-18 | 6 | Scientist | 1320h |
| 26 | 17.2 | Job Control/Database for Simulation [5533155] | 2011-10-03 | 2012-05-17 | 6 | Contributed; Scientist [10%] | 1440h |
| 27 | 18 | PWA Development [5533160] | 2011-10-03 | 2012-02-06 | 6 | Contributed; Scientist [10%] | 800h |
| 28 | 19 | PWA Challenge [5533165] | 2012-02-06 | 2012-02-15 | 27 | Contributed [50%]; Scientist | 80h |
| 29 | 20 | Grid Implementation [5533170] | 2012-05-21 | 2012-11-06 | 24 | Contributed [66%]; Scientist [33%] | 960h |
| 30 | 21 | Event Viewer (adapted from online) [5533175] | 2010-06-28 | 2010-11-26 | 2FS-4800h | Contributed; Scientist [10%] | 960h |
| 31 | 22 | Documentation [5533180] | 2010-06-21 | 2010-09-03 | 1FS-4800h | Contributed; Scientist | 880h |
| 32 | 23 | Coordination [-1] | 2009-10-01 | 2012-03-06 |  | Scientist [15%] | 760h |
